# PROGRAMACION CONTRACTUAL - CALLE LIMA

Schedule from MS Project, 2021-02-05 to 2021-03-06, status date 2021-02-28, A marks actual dates.

## Calendars

- calendario calle lima: Mon-Sun 07:00-12:00, 13:00-16:00.

## Schedule

| ID | WBS | Task | Type | Duration | Start | Finish | Predecessors | Complete | Remaining | Baseline start | Baseline finish | Baseline duration | Total slack |
| --- | --- | --- | --- | --- | --- | --- | --- | --- | --- | --- | --- | --- | --- |
| 1 | 1 | **ETAPA PRECONSTRUCCIÓN** |  | 30d | 2021-02-05 A | 2021-03-06 |  | 80% | 6d | 2021-02-05 | 2021-03-06 | 30d | 0d |
| 2 | 1.1 | ACTA DE INICIO/SUMINISTRO DE INFORMACION | milestone | 0d | 2021-02-05 A | 2021-02-05 A |  | 100% |  | 2021-02-05 | 2021-02-05 | 0d |  |
| 3 | 1.2 | **PRELIMINARES** |  | 30d | 2021-02-05 A | 2021-03-06 |  | 80% | 6d | 2021-02-05 | 2021-03-06 | 30d | 0d |
| 4 | 1.2.1 | INSTALACION CAMPAMENTO/acometida electrica/acometida hidraulica/instalacion internet/tramite permisos para ingreso personal y vehiculos |  | 30d | 2021-02-05 A | 2021-03-06 |  | 80% | 6d | 2021-02-05 | 2021-03-06 | 30d | 0d |
| 5 | 1.3 | **FASE A. ESTUDIOS Y DISEÑOS** |  | 30d | 2021-02-05 A | 2021-03-06 |  | 80% | 6d | 2021-02-05 | 2021-03-06 | 30d | 0d |
| 6 | 1.3.1 | **APROPIACION DE ESTUDIOS Y DISEÑOS** |  | 30d | 2021-02-05 A | 2021-03-06 |  | 80% | 6d | 2021-02-05 | 2021-03-06 | 30d | 0d |
| 7 | 1.3.1.1 | REVISIÓN Y ESTUDIO DE INFORMACIÓN SUMINISTRADA POR LA AERONAUTICA |  | 7d | 2021-02-05 A | 2021-02-11 A | 2SS | 100% |  | 2021-02-05 | 2021-02-11 | 7d |  |
| 8 | 1.3.1.2 | EVALUACION DE INFORMACION COMPILADA |  | 7d | 2021-02-12 A | 2021-02-18 A | 7 | 100% |  | 2021-02-12 | 2021-02-18 | 7d |  |
| 9 | 1.3.1.3 | SOLICITUD DE INFORMACION NECESARIA Y FALTANTE PARA APROPIACIÓN DE LOS DISEÑOS | milestone | 0d | 2021-02-18 A | 2021-02-18 A | 8 | 100% |  | 2021-02-18 | 2021-02-18 | 0d |  |
| 10 | 1.3.1.4 | ANALISIS DE INFORMACIÓN COMPLEMENTARIA RECIBIDA |  | 8d | 2021-02-19 A | 2021-02-26 A | 9 | 100% |  | 2021-02-19 | 2021-02-26 | 8d |  |
| 11 | 1.3.1.5 | INFORME FINAL DE APROPIACIÓN O NO DE DISEÑOS |  | 8d | 2021-02-27 A | 2021-03-06 | 10 | 25% | 6d | 2021-02-27 | 2021-03-06 | 8d | 0d |
| 12 | 1.3.1.6 | PROGRAMACION DETALLADA DE AJUSTE/ACTUALIZACION DE ESTUDIOS Y DISEÑOS | milestone | 0d | 2021-03-06 | 2021-03-06 | 11 |  |  | 2021-03-06 | 2021-03-06 | 0d | 0d |
| 13 | 1.4 | **FASE B. ADHESION DE OBRAS** |  | 30d | 2021-02-05 A | 2021-03-06 |  | 80% | 6d | 2021-02-05 | 2021-03-06 | 30d | 0d |
| 14 | 1.4.1 | **APROPIACIÓN DE LAS OBRAS POR ADHESION** |  | 30d | 2021-02-05 A | 2021-03-06 |  | 80% | 6d | 2021-02-05 | 2021-03-06 | 30d | 0d |
| 15 | 1.4.1.1 | REVISIÓN Y ESTUDIO DE INFORMACIÓN OBRAS EJECUTADAS |  | 7d | 2021-02-05 A | 2021-02-11 A | 2SS | 100% |  | 2021-02-05 | 2021-02-11 | 7d |  |
| 16 | 1.4.1.2 | EVALUACION DE INFORMACION Y CATASTRO DE OBRAS |  | 7d | 2021-02-12 A | 2021-02-18 A | 15 | 100% |  | 2021-02-12 | 2021-02-18 | 7d |  |
| 17 | 1.4.1.3 | SOLICITUD DE INFORMACION NECESARIA Y FALTANTE PARA APROPIACIÓN DE LOS DISEÑOS | milestone | 0d | 2021-02-18 A | 2021-02-18 A | 16 | 100% |  | 2021-02-18 | 2021-02-18 | 0d |  |
| 18 | 1.4.1.4 | ANALISIS DE INFORMACIÓN COMPLEMENTARIA RECIBIDA |  | 8d | 2021-02-19 A | 2021-02-26 A | 17 | 100% |  | 2021-02-19 | 2021-02-26 | 8d |  |
| 19 | 1.4.1.5 | INFORME FINAL DE APROPIACIÓN O NO DE DISEÑOS |  | 8d | 2021-02-27 A | 2021-03-06 | 18 | 25% | 6d | 2021-02-27 | 2021-03-06 | 8d | 0d |
| 20 | 1.4.1.6 | PROGRAMA DETALLADO DE VERIFICACION DE ESTADO | milestone | 0d | 2021-03-06 | 2021-03-06 | 19 |  |  | 2021-03-06 | 2021-03-06 | 0d | 0d |
