# PORGRAMACION CONTRACTUAL - CALLELIMA

Schedule from MS Project, 2021-02-05 to 2022-06-04, status date 2021-02-28, A marks actual dates.

## Calendars

- calendario calle lima: Mon-Sun 07:00-12:00, 13:00-16:00.

## Schedule

| ID | WBS | Task | Type | Duration | Start | Finish | Predecessors | Complete | Remaining | Baseline start | Baseline finish | Baseline duration | Total slack | % ejecutado |
| --- | --- | --- | --- | --- | --- | --- | --- | --- | --- | --- | --- | --- | --- | --- |
| 1 | 1 | **ETAPA PRECONSTRUCCIÓN** |  | 120d | 2021-02-05 A | 2021-06-04 |  | 6% | 113.39d | 2021-02-05 | 2021-06-04 | 120d | 0d | 6% |
| 2 | 1.1 | ACTA DE INICIO/SUMINISTRO DE INFORMACION | milestone | 0d | 2021-02-05 A | 2021-02-05 A |  | 100% |  | 2021-02-05 | 2021-02-05 | 0d |  | 100% |
| 3 | 1.2 | **PRELIMINARES** |  | 30d | 2021-02-05 A | 2021-03-06 |  | 77% | 6.88d | 2021-02-05 | 2021-03-06 | 30d | 90d | 77% |
| 4 | 1.2.1 | INSTALACION CAMPAMENTO/acometida electrica/acometida hidraulica/instalacion internet/tramite permisos para ingreso personal y vehiculos |  | 30d | 2021-02-05 A | 2021-03-06 |  | 77% | 6.88d | 2021-02-05 | 2021-03-06 | 30d | 90d | 77% |
| 5 | 1.3 | **FASE A. ESTUDIOS Y DISEÑOS** |  | 120d | 2021-02-05 A | 2021-06-04 |  | 2% | 117.5d | 2021-02-05 | 2021-06-04 | 120d | 0d | 2% |
| 6 | 1.3.1 | **APROPIACION DE ESTUDIOS Y DISEÑOS** |  | 30d | 2021-02-05 A | 2021-03-06 |  | 77% | 6.88d | 2021-02-05 | 2021-03-06 | 30d | 0d | 77% |
| 7 | 1.3.1.1 | REVISIÓN Y ESTUDIO DE INFORMACIÓN SUMINISTRADA POR LA AERONAUTICA |  | 7d | 2021-02-05 A | 2021-02-11 A | 2SS | 100% |  | 2021-02-05 | 2021-02-11 | 7d |  | 100% |
| 8 | 1.3.1.2 | EVALUACION DE INFORMACION COMPILADA |  | 7d | 2021-02-12 A | 2021-02-18 A | 7 | 100% |  | 2021-02-12 | 2021-02-18 | 7d |  | 100% |
| 9 | 1.3.1.3 | SOLICITUD DE INFORMACION NECESARIA Y FALTANTE PARA APROPIACIÓN DE LOS DISEÑOS | milestone | 0d | 2021-02-18 A | 2021-02-18 A | 8 | 100% |  | 2021-02-18 | 2021-02-18 | 0d |  | 100% |
| 10 | 1.3.1.4 | ANALISIS DE INFORMACIÓN COMPLEMENTARIA RECIBIDA |  | 8d | 2021-02-19 A | 2021-02-26 A | 9 | 100% |  | 2021-02-19 | 2021-02-26 | 8d |  | 100% |
| 11 | 1.3.1.5 | INFORME FINAL DE APROPIACIÓN O NO DE DISEÑOS |  | 8d | 2021-02-27 A | 2021-03-06 | 10 | 14% | 6.88d | 2021-02-27 | 2021-03-06 | 8d | 0d | 14% |
| 12 | 1.3.1.6 | PROGRAMACION DETALLADA DE AJUSTE/ACTUALIZACION DE ESTUDIOS Y DISEÑOS | milestone | 0d | 2021-03-06 | 2021-03-06 | 11 |  |  | 2021-03-06 | 2021-03-06 | 0d | 0d | 0% |
| 13 | 1.3.2 | **AJUSTE /COMPLEMENTO /ACTUALIZACION ESTUDIOS Y DISEÑOS.** |  | 90d | 2021-03-07 | 2021-06-04 |  |  |  | 2021-03-07 | 2021-06-04 | 90d | 0d | 0% |
| 14 | 1.3.2.1 | **Complemento actualización entregable Topografía.** |  | 90d | 2021-03-07 | 2021-06-04 | 12 |  |  | 2021-03-07 | 2021-06-04 | 90d | 0d | 0% |
| 15 | 1.3.2.1.1 | Posicionamiento de bms y revision de carteras topograficas en zona 3 |  | 30d | 2021-03-07 | 2021-04-05 |  |  |  | 2021-03-07 | 2021-04-05 | 30d | 0d | 0% |
| 16 | 1.3.2.1.2 | Posicionamiento de bms y revision de carteras topograficas de calle de rodaje y elementos estructuralesen zona 2 |  | 30d | 2021-04-06 | 2021-05-05 | 15 |  |  | 2021-04-06 | 2021-05-05 | 30d | 0d | 0% |
| 17 | 1.3.2.1.3 | Posicionamiento de bms y revision de carteras topograficas en zona 4 |  | 30d | 2021-05-06 | 2021-06-04 | 16 |  |  | 2021-05-06 | 2021-06-04 | 30d | 0d | 0% |
| 18 | 1.3.2.2 | Complemento actualización entregable Diseño geométrico. |  | 90d | 2021-03-07 | 2021-06-04 | 12 |  |  | 2021-03-07 | 2021-06-04 | 90d | 0d | 0% |
| 19 | 1.3.2.3 | Complemento actualización entregable Estudio de suelos y diseño geotécnico. |  | 90d | 2021-03-07 | 2021-06-04 | 12 |  |  | 2021-03-07 | 2021-06-04 | 90d | 0d | 0% |
| 20 | 1.3.2.4 | Complemento actualización entregable Redes y edificaciones existentes. |  | 90d | 2021-03-07 | 2021-06-04 | 12 |  |  | 2021-03-07 | 2021-06-04 | 90d | 0d | 0% |
| 21 | 1.3.2.5 | Complemento actualización entregable Estudios y diseños pavimentos. |  | 90d | 2021-03-07 | 2021-06-04 | 12 |  |  | 2021-03-07 | 2021-06-04 | 90d | 0d | 0% |
| 22 | 1.3.2.6 | Complemento actualización entregable Estudios y diseños estructurales. |  | 90d | 2021-03-07 | 2021-06-04 | 12 |  |  | 2021-03-07 | 2021-06-04 | 90d | 0d | 0% |
| 23 | 1.3.2.7 | Complemento actualización entregable Estudios y diseños hidráulicos. |  | 90d | 2021-03-07 | 2021-06-04 | 12 |  |  | 2021-03-07 | 2021-06-04 | 90d | 0d | 0% |
| 24 | 1.3.2.8 | Complemento actualización entregable Estudios y diseños eléctricos. |  | 90d | 2021-03-07 | 2021-06-04 | 12 |  |  | 2021-03-07 | 2021-06-04 | 90d | 0d | 0% |
| 25 | 1.3.2.9 | Complemento actualización entregable Información ambiental y social |  | 90d | 2021-03-07 | 2021-06-04 | 12 |  |  | 2021-03-07 | 2021-06-04 | 90d | 0d | 0% |
| 26 | 1.3.2.10 | Complemento actualización entregable Diseños de señalización horizontal. |  | 90d | 2021-03-07 | 2021-06-04 | 12 |  |  | 2021-03-07 | 2021-06-04 | 90d | 0d | 0% |
| 27 | 1.3.2.11 | Complemento actualización entregable Diseños urbanos y obras de arte. |  | 90d | 2021-03-07 | 2021-06-04 | 12 |  |  | 2021-03-07 | 2021-06-04 | 90d | 0d | 0% |
| 28 | 1.3.2.12 | Complemento actualización entregable Especificaciones y presupuesto |  | 90d | 2021-03-07 | 2021-06-04 | 12 |  |  | 2021-03-07 | 2021-06-04 | 90d | 0d | 0% |

| ID | WBS | Task | Type | Duration | Start | Finish | Predecessors | Complete | Remaining | Baseline start | Baseline finish | Baseline duration | Total slack | % ejecutado |
| --- | --- | --- | --- | --- | --- | --- | --- | --- | --- | --- | --- | --- | --- | --- |
| 29 | 1.4 | **FASE B. ADHESION DE OBRAS** |  | 120d | 2021-02-05 A | 2021-06-04 |  | 19% | 96.88d | 2021-02-05 | 2021-06-04 | 120d | 0d | 19% |
| 30 | 1.4.1 | **APROPIACIÓN DE LAS OBRAS POR ADHESION** |  | 30d | 2021-02-05 A | 2021-03-06 |  | 77% | 6.88d | 2021-02-05 | 2021-03-06 | 30d | 0d | 77% |
| 31 | 1.4.1.1 | REVISIÓN Y ESTUDIO DE INFORMACIÓN OBRAS EJECUTADAS |  | 7d | 2021-02-05 A | 2021-02-11 A | 2SS | 100% |  | 2021-02-05 | 2021-02-11 | 7d |  | 100% |
| 32 | 1.4.1.2 | EVALUACION DE INFORMACION Y CATASTRO DE OBRAS |  | 7d | 2021-02-12 A | 2021-02-18 A | 31 | 100% |  | 2021-02-12 | 2021-02-18 | 7d |  | 100% |
| 33 | 1.4.1.3 | SOLICITUD DE INFORMACION NECESARIA Y FALTANTE PARA APROPIACIÓN DE LOS DISEÑOS | milestone | 0d | 2021-02-18 A | 2021-02-18 A | 32 | 100% |  | 2021-02-18 | 2021-02-18 | 0d |  | 100% |
| 34 | 1.4.1.4 | ANALISIS DE INFORMACIÓN COMPLEMENTARIA RECIBIDA |  | 8d | 2021-02-19 A | 2021-02-26 A | 33 | 100% |  | 2021-02-19 | 2021-02-26 | 8d |  | 100% |
| 35 | 1.4.1.5 | INFORME FINAL DE APROPIACIÓN O NO DE DISEÑOS |  | 8d | 2021-02-27 A | 2021-03-06 | 34 | 14% | 6.88d | 2021-02-27 | 2021-03-06 | 8d | 0d | 14% |
| 36 | 1.4.1.6 | PROGRAMA DETALLADO DE VERIFICACION DE ESTADO | milestone | 0d | 2021-03-06 | 2021-03-06 | 35 |  |  | 2021-03-06 | 2021-03-06 | 0d | 0d | 0% |
| 37 | 1.4.2 | **VERIFICACION DEL ESTADO/CALIDAD/ESTABILIDAD DE OBRAS** |  | 90d | 2021-03-07 | 2021-06-04 |  |  |  | 2021-03-07 | 2021-06-04 | 90d | 0d | 0% |
| 38 | 1.4.2.1 | ENSAYOS Y ESTUDIOS NECESARIOS PARA LA VERIFICACION Y ESTABILIDAD DE OBRA |  | 90d | 2021-03-07 | 2021-06-04 | 36 |  |  | 2021-03-07 | 2021-06-04 | 90d | 0d | 0% |
| 39 | 2 | ETAPA DE CONSTRUCCION |  | 365d | 2021-06-05 | 2022-06-04 | 1 |  |  | 2021-06-05 | 2022-06-04 | 365d | 0d | 0% |
| 40 | 3 | FIN DEL CONTRATO | milestone | 0d | 2022-06-04 | 2022-06-04 | 39 |  |  | 2022-06-04 | 2022-06-04 | 0d | 0d | 0% |
